Schedule from MS Project, 2026-06-12 to 2026-09-03.

## Calendars

- Estándar: Mon-Fri 09:00-13:00, 15:00-19:00; Sat-Sun off.

## Resources

| Resource | Unit | Rate |
| --- | --- | --- |
| Aceite quemado | gal | 0.6 |
| Acero de refuerzo fy=4200kg/cm2 | kg | 1.35 |
| Agua en m3 | m3 | 1.05 |
| Alambre galvanizado # 18 | kg | 2.36 |
| alfajias 0.04*0.04*2.40 m | u | 1.5 |
| Arena | m3 | 9.78 |
| Caña Guadua | m. | 0.37 |
| Cemento Portland | kg | 0.17 |
| Clavos 2 1/2" | kg | 1.7 |
| Encofrado para pozos hormigón | m. | 3 |
| Estacas (30 cm) | u | 0.35 |
| Lubricante | Lt | 1.1 |
| Piedra bola | m3 | 10.35 |
| Pintura anticorrosiva | gal | 18.46 |
| Pintura esmalte | gal | 18.25 |
| Ripio (3/4") - material triturado | m3 | 13.8 |
| Sumidero H.S. d=600 mm | u | 30 |
| sumidero rectang 600x300mm HD | u | 174.91 |
| Tabla de encofrado 0.30*2.40 m | u | 3.5 |
| tapa redonda HD 600mm | u | 261.33 |
| tiras (2.4x0.025x0.025) - Metros | m. | 0.37 |
| tubería PVC para alcantarillado di=200mm | m. | 11.18 |
| tubería PVC para alcantarillado di=250mm | m. | 13.83 |
| tubería PVC para alcantarillado di=300mm | m. | 20.4 |
| tubería PVC para alcantarillado di=400mm | m. | 35.34 |
| tubería PVC para alcantarillado di=500mm | m. | 56.64 |
| tubería PVC para alcantarillado di=700mm | m. | 103.24 |
| Albañil |  | 4.39 |
| Ayudante de Albañil |  | 4.34 |
| Ayudante de fierrero |  | 4.34 |
| Cadenero |  | 4.39 |
| Chofer profesional de volqueta |  | 6.38 |
| Encofrador o carpintero de ribera |  | 4.39 |
| Fierrero |  | 4.39 |
| Maestro mayor en ejecucion de obras civiles |  | 4.87 |
| OPERADOR cargadora frontal |  | 4.87 |
| OPERADOR Retroexcavadora |  | 4.87 |
| Peón |  | 4.34 |
| TOPOGRAFO (En Construcción) |  | 4.87 |
| Cargadora Frontal |  | 55 |
| Concretera 1 Saco |  | 6.5 |
| Cortadora de Hierro |  | 3.5 |
| Estación Total |  | 7.5 |
| Herramienta menor |  | 1 |
| Nivel Laser |  | 1.5 |
| Retroexcavadora (de llanta) |  | 35 |
| Vibrador |  | 3.5 |
| Vibro compactador(de plancha) |  | 4.25 |
| Volqueta 12m3 |  | 35 |
| Transporte |  |  |

## Schedule

| ID | Task | Type | Duration | Start | Finish | Predecessors |
| --- | --- | --- | --- | --- | --- | --- |
| 1 | PROYECTO | manual | 60d | 2026-06-12 | 2026-09-03 |  |
| 2 | Replanteo y nivelación para redes hidrosanitarias. | manual | 6d | 2026-06-12 | 2026-06-19 |  |
| 3 | Rasanteo y preparación zanja (inc. Cama de arena). | manual | 15d | 2026-06-26 | 2026-07-16 |  |
| 4 | Excavación de suelo natural <2 m (a máquina). | manual | 40d | 2026-06-17 | 2026-08-11 | 2 |
| 5 | Excavación de suelo natural 2 a 4 m (a máquina). | manual | 20d | 2026-08-04 | 2026-08-31 | 4 |
| 6 | Excavación de suelo natural 2 a 4 m (a máquina). | manual | 2d | 2026-08-31 | 2026-09-01 | 5 |
| 7 | Desalojo a máquina (dist= 5 km). | manual | 30d | 2026-07-17 | 2026-08-27 | 5 |
| 8 | Relleno compactado (suelo natural). | manual | 45d | 2026-06-29 | 2026-08-28 | 23 |
| 9 | Sum/Ins/Tra Sumidero H.S. d=600 mm salida 200mm. | manual | 20d | 2026-07-17 | 2026-08-13 | 4 |
| 10 | Sum/Ins/Tra Rejilla Sumidero HD 600x300mm. | manual | 5d | 2026-08-25 | 2026-08-31 | 9 |
| 11 | Losa de Tapa HA para pozo revisión e=0.20m d=1.40m. | manual | 10d | 2026-06-19 | 2026-07-02 | 15 |
| 12 | Base H.C. del pozo de revisión d=1.50m e=0.30m. | manual | 5d | 2026-08-25 | 2026-08-31 | 5 |
| 13 | Sum/Ins/Tra Tapa Redonda HD 600mm. | manual | 5d | 2026-06-29 | 2026-07-03 | 11 |
| 14 | Pozo de Revisión H.S f`c=210kg/cm2 h=0-2m di=1m (el cuerpo). | manual | 10d | 2026-07-02 | 2026-07-15 | 12 |
| 15 | Pozo de Revisión H.S f`c=210kg/cm2 h=2-4m di=1m (el cuerpo). | manual | 5d | 2026-07-16 | 2026-07-22 | 14 |
| 16 | Pozo de Revisión H.S f`c=210kg/cm2 h=4-6m di=1m (el cuerpo). | manual | 5d | 2026-07-23 | 2026-07-29 | 15 |
| 17 | Entibado | manual | 1d | 2026-08-26 | 2026-08-26 | 6 |
| 18 | Sum/Ins/Tra Tubería PVC para alcantarillado dn=220mm. | manual | 20d | 2026-06-29 | 2026-07-24 | 3 |
| 19 | Sum/Ins/Tra Tubería PVC para alcantarillado dn=280mm. | manual | 10d | 2026-06-29 | 2026-07-10 | 3 |
| 20 | Sum/Ins/Tra Tubería PVC para alcantarillado dn=335mm. | manual | 10d | 2026-06-29 | 2026-07-10 | 3 |
| 21 | Sum/Ins/Tra Tubería PVC para alcantarillado dn=440mm. | manual | 5d | 2026-06-29 | 2026-07-03 | 3 |
| 22 | Sum/Ins/Tra Tubería PVC para alcantarillado dn=650mm. | manual | 6d | 2026-07-17 | 2026-07-24 | 3 |
| 23 | Hormigón Simple en replantillos f`c=140 kg/cm2. | manual | 0.5d | 2026-07-27 | 2026-07-27 | 22 |
| 24 | Hormigón simple f`c=210 kg/cm2 con encofrado. | manual | 1d | 2026-07-17 | 2026-07-17 | 25 |
| 25 | Sum/Ins/Tra Acero de Refuerzo fy=4200 kg/cm2. | manual | 2d | 2026-07-20 | 2026-07-21 | 5 |
| 26 | Sum/Ins/Tra Estribos de pozo de revisión d=16mm. | manual | 4d | 2026-07-29 | 2026-08-03 | 15 |
